# WBS

Schedule from MS Project, 2024-03-01 to 2024-10-07.

## Calendars

- Standard: Mon-Fri 08:00-12:00, 13:00-17:00; Sat-Sun off.

## Schedule

| ID | WBS | Task | Type | Duration | Start | Finish | Predecessors | Total slack | Free slack |
| --- | --- | --- | --- | --- | --- | --- | --- | --- | --- |
| 1 | 1 | **1 Project Planning and Preparation** |  | 18d | 2024-03-01 | 2024-03-26 |  |  |  |
| 2 | 1.1 | 1.1 Define research objectives and scope |  | 1d | 2024-03-01 | 2024-03-01 |  | 44d | 0d |
| 3 | 1.2 | 1.2 Conduct literature review on cavitation erosion and Stellite materials |  | 14d | 2024-03-04 | 2024-03-21 | 2 | 44d | 0d |
| 4 | 1.3 | 1.3 Develop research methodology |  | 2d | 2024-03-22 | 2024-03-25 | 3 | 44d | 0d |
| 5 | 1.4 | 1.4 Obtain feedback |  | 1d | 2024-03-26 | 2024-03-26 | 4 | 124d | 0d |
| 6 | 1.5 | 1.5 Deliverable - Aims & Objectives | milestone | 0d | 2024-03-26 | 2024-03-26 | 5 | 139d |  |
| 7 | 1.6 | **1.6 Resource Management** |  | 4d | 2024-03-04 | 2024-03-07 | 2 | 56d |  |
| 8 | 1.6.1 | 1.6.1 Define Resource Requirements |  | 1d | 2024-03-04 | 2024-03-04 | 2 | 56d | 0d |
| 9 | 1.6.2 | 1.6.2 Identification of types of resources needed (e.g., personnel, equipment, materials) |  | 1d | 2024-03-05 | 2024-03-05 | 8 | 56d | 0d |
| 10 | 1.6.3 | 1.6.3 Resource - Personnel |  | 1d | 2024-03-06 | 2024-03-06 | 9 | 56d | 0d |
| 11 | 1.6.4 | 1.6.4 Resource - Equipment |  | 1d | 2024-03-07 | 2024-03-07 | 10 | 56d | 0d |
| 12 | 1.6.5 | 1.6.5 Deliverable - Resource Management | milestone | 0d | 2024-03-07 | 2024-03-07 | 11 | 152d |  |
| 13 | 1.7 | **1.7 Risk Management** |  | 8d | 2024-03-08 | 2024-03-19 |  | 140d |  |
| 14 | 1.7.1 | 1.7.1 Identification of risks |  | 1d | 2024-03-08 | 2024-03-08 | 11 | 140d | 0d |
| 15 | 1.7.2 | 1.7.2 Identification of Likelihood and Impact of Identified Risks |  | 5d | 2024-03-11 | 2024-03-15 | 14 | 140d | 0d |
| 16 | 1.7.3 | 1.7.3 Identify Risk Mitigation Strategies |  | 2d | 2024-03-18 | 2024-03-19 | 15 | 140d | 0d |
| 17 | 1.7.4 | 1.7.4 Deliverable - Risk Management | milestone | 0d | 2024-03-19 | 2024-03-19 | 16 | 140d | 0d |
| 18 | 1.8 | **1.8 Beneficiaries & Stakeholder** |  | 4d | 2024-03-20 | 2024-03-25 |  | 140d |  |
| 19 | 1.8.1 | 1.8.1 Identification of beneficiaries |  | 2d | 2024-03-20 | 2024-03-21 | 17 | 140d | 0d |
| 20 | 1.8.2 | 1.8.2 Identification of stakeholders |  | 2d | 2024-03-22 | 2024-03-25 | 19 | 140d | 0d |
| 21 | 1.8.3 | 1.8.3 Deliverable - Beneficiaries & Stakeholder | milestone | 0d | 2024-03-25 | 2024-03-25 | 20 | 140d |  |
| 22 | 2 | **2 Material Preparation** |  | 15d | 2024-03-27 | 2024-04-16 |  | 124d |  |
| 23 | 2.1 | 2.1 Procure Stellite samples of different compositions |  | 1d | 2024-03-27 | 2024-03-27 | 5 | 124d | 0d |
| 24 | 2.2 | 2.2 Prepare Stellite samples for testing (e.g., cutting, shaping, polishing) |  | 7d | 2024-03-28 | 2024-04-05 | 23 | 124d | 0d |
| 25 | 2.3 | 2.3 Characterize Stellite samples (images, density measurement, marking, inventory management) |  | 7d | 2024-04-08 | 2024-04-16 | 24 | 124d | 0d |
| 26 | 2.4 | 2.4 Milestone - Sample handover | milestone | 0d | 2024-04-16 | 2024-04-16 | 25 | 124d |  |

| ID | WBS | Task | Type | Duration | Start | Finish | Predecessors | Total slack | Free slack | Constraint |
| --- | --- | --- | --- | --- | --- | --- | --- | --- | --- | --- |
| 27 | 3 | **3 Experimental Rig Setup** |  | 55d | 2024-03-26 | 2024-06-10 | 11 | 44d |  |  |
| 28 | 3.1 | 3.1 Design cavitation erosion test rig |  | 14d | 2024-03-26 | 2024-04-12 | 4 | 44d | 0d |  |
| 29 | 3.2 | 3.2 Review cavitation erosion design - Ahmed Algoburi |  | 2d | 2024-04-15 | 2024-04-16 | 28 | 44d | 0d |  |
| 30 | 3.3 | 3.3 Review cavitation erosion design - Dr Rehan Ahmed |  | 2d | 2024-04-17 | 2024-04-18 | 29 | 44d | 0d |  |
| 31 | 3.4 | 3.4 Review cavitation erosion design - Dr Mohammed Al-Musleh |  | 2d | 2024-04-19 | 2024-04-22 | 30 | 44d | 0d |  |
| 32 | 3.5 | 3.5 Review cavitation erosion design - Muhsin Aykapadattu |  | 2d | 2024-04-23 | 2024-04-24 | 31 | 44d | 0d |  |
| 33 | 3.6 | 3.6 Milestone - Acquire equipment for cavitation erosion rig | milestone | 0d | 2024-04-24 | 2024-04-24 | 32 | 44d | 0d |  |
| 34 | 3.7 | 3.7 Structure Assembly |  | 7d | 2024-04-25 | 2024-05-03 | 33 | 44d | 0d |  |
| 35 | 3.8 | 3.8 Milestone - Assemble Design | milestone | 0d | 2024-05-03 | 2024-05-03 | 34 | 44d | 0d |  |
| 36 | 3.9 | 3.9 Mounting of Equipment |  | 7d | 2024-05-06 | 2024-05-14 | 35 | 44d | 0d |  |
| 37 | 3.10 | 3.10 Milestone - Equipment Mounted | milestone | 0d | 2024-05-14 | 2024-05-14 | 36 | 44d | 0d |  |
| 38 | 3.11 | 3.11 Wiring of Power Cables |  | 3d | 2024-05-15 | 2024-05-17 | 37 | 44d | 0d |  |
| 39 | 3.12 | 3.12 Wiring of Signal Cables |  | 4d | 2024-05-20 | 2024-05-23 | 38 | 44d | 0d |  |
| 40 | 3.13 | 3.13 Connection of Fluid Cables |  | 1d | 2024-05-24 | 2024-05-24 | 39 | 44d | 0d |  |
| 41 | 3.14 | 3.14 Calibrate instrumentation (e.g., ultrasonic transducers, pressure sensors) |  | 4d | 2024-05-27 | 2024-05-30 | 40 | 44d | 0d |  |
| 42 | 3.15 | 3.15 Milestone - Equipment Components functional | milestone | 0d | 2024-05-30 | 2024-05-30 | 41 | 44d | 0d |  |
| 43 | 3.16 | 3.16 Integration Testing |  | 7d | 2024-05-31 | 2024-06-10 | 42 | 44d | 0d |  |
| 44 | 3.17 | 3.17 Milestone - Stainless steel samples | milestone | 0d | 2024-06-10 | 2024-06-10 | 43 | 44d | 0d |  |
| 45 | 4 | 4 Cavitation Testing | manual | 28d | 2024-06-11 | 2024-07-18 | 44 |  |  |  |
| 46 | 5 | **5 Data Analysis** |  | 13d | 2024-07-19 | 2024-08-06 |  | 44d |  |  |
| 47 | 5.1 | 5.1 Process experimental data (e.g., erosion depth measurements, surface roughness data) |  | 5d | 2024-07-19 | 2024-07-25 | 45 | 44d | 0d |  |
| 48 | 5.2 | 5.2 Fit to parameter models |  | 3d | 2024-07-26 | 2024-07-30 | 47 | 44d | 0d |  |
| 49 | 5.3 | 5.3 Analyze cavitation erosion mechanisms and patterns |  | 5d | 2024-07-31 | 2024-08-06 | 48 | 44d |  |  |
| 50 | 6 | **6 Material characterization** |  | 73d | 2024-04-22 | 2024-07-31 |  | 38d |  |  |
| 51 | 6.1 | 6.1 EDM Wire Cutting |  | 7d | 2024-04-22 | 2024-04-30 |  | 38d | 37d |  |
| 52 | 6.2 | 6.2 Sample Preparation |  | 7d | 2024-06-21 | 2024-07-01 | 51 | 1d |  | finish no earlier than 2024-07-01 |
| 53 | 6.3 | 6.3 Resin Casting |  | 1d | 2024-07-03 | 2024-07-03 | 52 | 0d |  | finish no earlier than 2024-07-03 |
| 54 | 6.4 | 6.4 SEM & EDS - Visit 1 |  | 3d | 2024-07-08 | 2024-07-10 | 53 | 54d | 2d | finish no earlier than 2024-07-10 |
| 55 | 6.5 | 6.5 SEM & EDS - Visit 2 |  | 3d | 2024-07-15 | 2024-07-17 | 54 | 52d | 2d | finish no earlier than 2024-07-17 |
| 56 | 6.6 | 6.6 SEM & EDS - Visit 3 |  | 3d | 2024-07-22 | 2024-07-24 | 55 | 50d | 2d | finish no earlier than 2024-07-24 |
| 57 | 6.7 | 6.7 SEM & EDS - Visit 4 |  | 3d | 2024-07-29 | 2024-07-31 | 56 | 48d |  | finish no earlier than 2024-07-31 |

| ID | WBS | Task | Duration | Start | Finish | Predecessors | Total slack |
| --- | --- | --- | --- | --- | --- | --- | --- |
| 58 | 7 | **7 Reporting and Documentation** | 1d | 2024-04-22 | 2024-04-22 |  |  |
| 59 | 7.1 | 7.1 Create visualizations (e.g., graphs, charts) to illustrate findings | 2d | 2024-07-04 | 2024-07-05 | 53 | 0d |
| 60 | 7.2 | 7.2 Adapt Literature Review | 7d | 2024-07-08 | 2024-07-16 | 59 | 0d |
| 61 | 7.3 | 7.3 Milestone - Report - Introduction | 5d | 2024-07-17 | 2024-07-23 | 60 | 0d |
| 62 | 7.4 | 7.4 Milestone - Report - Methodology | 3d | 2024-07-24 | 2024-07-26 | 61 | 0d |
| 63 | 7.5 | 7.5 Milestone - Report - Results & Discussion | 5d | 2024-07-29 | 2024-08-02 | 62 | 0d |
| 64 | 7.6 | 7.6 Milestone - Report - Conclusion | 2d | 2024-08-05 | 2024-08-06 | 63 | 0d |
| 65 | 7.7 | 7.7 Milestone - Report - Abstract | 1d | 2024-08-07 | 2024-08-07 | 64 | 0d |
| 66 | 8 | **8 Presentation** | 7d | 2024-08-08 | 2024-08-16 |  | 0d |
| 67 | 8.1 | 8.1 Create presentation materials (e.g., slides) | 5d | 2024-08-08 | 2024-08-14 | 65 | 0d |
| 68 | 8.2 | 8.2 Practice oral presentation | 2d | 2024-08-15 | 2024-08-16 | 67 | 36d |
| 69 | 9 | **9 Publication** | 38d | 2024-08-15 | 2024-10-07 |  | 0d |
| 70 | 9.1 | 9.1 Write conference paper | 12d | 2024-08-15 | 2024-08-30 | 67 | 0d |
| 71 | 9.2 | 9.2 Present research findings at conferences, seminars, or workshops | 2d | 2024-09-02 | 2024-09-03 | 70 | 0d |
| 72 | 9.3 | 9.3 Write journal paper | 21d | 2024-09-04 | 2024-10-02 | 71 | 0d |
| 73 | 9.4 | 9.4 Publish research findings in scientific journals or other relevant publications | 3d | 2024-10-03 | 2024-10-07 | 72 | 0d |
